# programacion silvania febrero 8 - semanas

Schedule from MS Project, 2023-02-03 to 2023-04-01, status date 2023-02-05, A marks actual dates.

## Calendars

- OBRA INGENIARCOL: Mon-Sat 07:00-12:01, 13:01-17:00; Sun off. Exceptions (off unless hours are given): 2023-02-20 (FESTIVO DIA DE SAN JOSE, recurring).

## Schedule

| ID | WBS | Task | Type | Duration | Start | Finish | Predecessors | Complete | Remaining | Total slack | Free slack | Constraint |
| --- | --- | --- | --- | --- | --- | --- | --- | --- | --- | --- | --- | --- |
| 1 | 1 | **Const. Obras complementarias insti. Educativa Santa Ines - Municipio de Silvania.** |  | 55d | 2023-02-03 A | 2023-04-01 |  | 6% | 51.45d | 0d |  |  |
| 2 | 1.1 | INICIO ETAPA DE CONSTRUCCION | milestone | 0d | 2023-02-03 A | 2023-02-03 A |  | 100% |  |  |  |  |
| 3 | 1.2 | **EXCAVACIONES, RELLENOS Y REMPLAZOS** |  | 26d | 2023-02-03 A | 2023-03-03 |  | 27% | 19d | 29d |  |  |
| 4 | 1.2.1 | COMISION TOPOGRAFICA (replanteo) |  | 6d | 2023-02-03 A | 2023-02-09 | 2 | 95% | 0.3d | 4d | 0d |  |
| 5 | 1.2.2 | EXCAVACION EN ROCA CON EQUIPO NEUMATICO (INC. C-T-DF) |  | 20d | 2023-02-09 A | 2023-03-03 | 4, 2 | 20% | 16d | 29d | 0d |  |
| 6 | 1.2.3 | EXCAVACION MANUAL EN MATERIAL COMUN (INC. C-R) |  | 8d | 2023-02-13 A | 2023-02-22 | 5SS+4d | 20% | 6.4d | 0d |  |  |
| 7 | 1.2.4 | RELLENO EN RECEBO COMUN (SUMINISTRO, EXTEN, HUM Y COM) |  | 8d | 2023-02-23 | 2023-03-03 | 6 |  |  | 0d |  | start no earlier than 2023-01-30 |
| 8 | 1.3 | **CONCRETOS PARA CIMENTACION** |  | 9d | 2023-03-03 | 2023-03-13 |  |  |  | 7.96d |  |  |
| 9 | 1.3.1 | CONCRETO CICLOPEO - 40% CONC. 2500 PSI |  | 2d | 2023-03-04 | 2023-03-06 | 10 |  |  | 7.96d | 0d | start no earlier than 2023-01-30 |
| 10 | 1.3.2 | CONCRETO DE LIMPIEZA 1500 PSI |  | 1d | 2023-03-03 | 2023-03-03 | 7 |  |  | 7.96d | 0d | start no earlier than 2023-01-31 |
| 11 | 1.3.3 | CONCRETO PARA VIGAS DE CIMENTACION 3000 PSI |  | 1d | 2023-03-06 | 2023-03-07 | 9 |  |  | 7.96d | 0d |  |
| 12 | 1.3.4 | CONCRETO PARA ZAPATAS 3000 PSI |  | 6d | 2023-03-06 | 2023-03-13 | 9 |  |  | 14d | 0d | start no earlier than 2023-01-31 |
| 13 | 1.4 | **ACERO DE REFUERZO PARA CIMENT - ESTRUC - MAMPOS Y OTRO** |  | 8d | 2023-02-09 | 2023-02-17 |  |  |  | 6d |  |  |
| 14 | 1.4.1 | ACERO DE REFUERZO 60000 PSI |  | 8d | 2023-02-09 | 2023-02-17 | 5SS |  |  | 6d | 0d | start no earlier than 2023-01-27 |
| 15 | 1.5 | **ELEMENTOS ESCTRUCTURALES Y NO ESTRUCTURALES** |  | 12d | 2023-03-06 | 2023-03-18 |  |  |  | 14d |  |  |
| 16 | 1.5.1 | ANCLAJE PARA REFORZAMIENTO EN CONCRETO Y EPOXICO PARA (D = 1/2") - 11 CM DE PROF ESTANDAR (PERF-LIMP-EPOX) |  | 12d | 2023-03-06 | 2023-03-18 | 12SS |  |  | 14d |  | start no earlier than 2023-02-06 |
| 17 | 1.6 | **MAMPOSTERIA EN LADRILLO TOLETE Y HUECO** |  | 12d | 2023-03-07 | 2023-03-20 |  |  |  | 7.96d |  |  |
| 18 | 1.6.1 | MURO EN LADRILLO ESTRUCTURAL E = 15 CM. NO INCLUYE REF |  | 12d | 2023-03-07 | 2023-03-20 | 11 |  |  | 7.96d | 0d |  |
| 19 | 1.7 | **ASEO Y LIMPIEZA** |  | 13d | 2023-03-20 | 2023-04-01 |  |  |  | 0d |  |  |
| 20 | 1.7.1 | LAVADO Y LIMPEZA DE FACHADA EN LADRILLO A LA VISTA |  | 5.04d | 2023-03-20 | 2023-03-24 | 18 |  |  | 7.96d |  |  |
| 21 | 1.7.2 | ASEO GENERAL |  | 4d | 2023-03-29 | 2023-04-01 | 27 |  |  | 0d |  | start no earlier than 2023-03-20 |
| 22 | 1.8 | **CERRAMIENTOS Y MOVILARIO URBANO** |  | 35d | 2023-02-17 | 2023-03-27 |  |  |  | 6d |  |  |
| 23 | 1.8.1 | CERRAMIENTO CONTRA IMPACTO H=5M (ESTRUCTURA EN TUBO GALVANIZADO DE 3". E=3.81 MM ASTM A500 Y CAMISA DE REFUERZO DE 4", VARILLA REDONDA DE 3/4" C. 14 EJES. VIGA 40X30 Y PILOTES CONCRETO 3000 PSI |  | 35d | 2023-02-17 | 2023-03-27 | 14 |  |  | 6d |  | start no earlier than 2023-01-29 |
| 24 | 1.9 | **ACTIVIDAD NO PREVISTA** |  | 37d | 2023-02-17 | 2023-03-29 |  |  |  | 4d |  |  |
| 25 | 1.9.1 | VIGUETA CONFINAMIENTO 20X25 EN CONCRETO 3000 PSI |  | 9d | 2023-02-17 | 2023-02-28 | 14 |  |  | 32d |  |  |
| 26 | 1.9.2 | COLUMNETA CONFINAMIENTO 20X25 EN CONCRETO 3000 PSI |  | 9d | 2023-02-17 | 2023-02-28 | 14 |  |  | 32d |  |  |
| 27 | 1.9.3 | SUMN E INST DE CERRAMIENTO EN MALLA ESLABONADA C. 10INC. ANGULO (PARA EL TUBO ESTRUCTURAL GALV 2" CADA 2.5M CON ALTURA DE 2.3M) PINTURA ANTICORROSIVA Y ACABADO EN ESMALTE PINTUCO O EQUIVALENTE |  | 25d | 2023-03-03 | 2023-03-29 | 7 |  |  | 0d |  |  |
| 28 | 1.9.4 | SUM E INST DE CERCA EN ALAMBRE DE PUA 2 HILOS |  | 4d | 2023-03-24 | 2023-03-29 | 27FF |  |  | 4d |  |  |
| 29 | 1.10 | FIN ETAPA DE CONSTRUCCION | milestone | 0d | 2023-03-23 | 2023-03-23 |  |  |  | 10d |  | start no earlier than 2023-03-23 |
